# CEREZAL REAL

Schedule from MS Project, 2022-05-02 to 2022-09-29.

## Calendars

- MI CALENDARIO: Mon-Sun 01:00-05:00, 08:00-12:00.

## Schedule

| ID | WBS | Task | Duration | Start | Finish | Predecessors | Total slack | Free slack | Comienzo de Tarea | Fin de Tarea | Días Calendarios |
| --- | --- | --- | --- | --- | --- | --- | --- | --- | --- | --- | --- |
| 1 | 1 | **"REHABILITACION DEL LOCAL ESCOLAR 14033 CON CODIGO LOCAL 414651 CENTRO POBLADO TUNAPE LA UNION - PIURA - PIURA"** | 150d | 2022-05-02 | 2022-09-29 |  |  |  |  |  |  |
| 2 | 1.1 | **OBRAS PROVISIONALES, TRABAJOS PRELIMINARES, SEGURIDAD Y SALUD** | 23d | 2022-05-02 | 2022-05-25 |  | 37d |  |  |  |  |
| 3 | 1.1.1 | **OBRAS PROVISIONALES** | 5d | 2022-05-02 | 2022-05-07 |  | 37d |  |  |  |  |
| 4 | 1.1.1.1 | ALMACEN, OFICINA Y CASETA DE GUARDIANIA | 4d | 2022-05-02 | 2022-05-06 |  | 37d | 0d | día 1036 | día 1040 | 1860 |
| 5 | 1.1.1.2 | CARTEL DE OBRA 2.40x3.60 | 1d | 2022-05-02 | 2022-05-03 | 4SS | 145d | 0d | día 1036 | día 1037 | 420 |
| 6 | 1.1.1.3 | SERVICIOS HIGIENICOS | 2d | 2022-05-03 | 2022-05-05 | 4SS+1d | 147d |  | día 1037 | día 1039 | 900 |
| 7 | 1.1.1.4 | AGUA PARA LA CONSTRUCCION | 1d | 2022-05-02 | 2022-05-03 | 4SS | 149d |  | día 1036 | día 1037 | 420 |
| 8 | 1.1.1.5 | ENERGIA ELECTRICA PARA LA CONSTRUCCION | 1d | 2022-05-02 | 2022-05-03 | 4SS | 149d |  | día 1036 | día 1037 | 420 |
| 9 | 1.1.1.6 | TRANSPORTE DE EQUIPO Y MAQUINARIA | 1d | 2022-05-06 | 2022-05-07 | 4 | 37d | 0d | día 1040 | día 1041 | 420 |
| 10 | 1.1.1.7 | AULA PREFABRICADA DE TRIPLEY DE 4mm, INC. LOSA | 3d | 2022-05-03 | 2022-05-06 | 5SS+1d | 145d | 0d | día 1037 | día 1040 | 1380 |
| 11 | 1.1.2 | **PLAN DE CONTINGENCIA** | 5d | 2022-05-02 | 2022-05-07 |  | 145d |  | día 0 | día 1 | 420 |
| 12 | 1.1.2.1 | CERCO PROVICIONAL DE MALLA RASCHEL | 2d | 2022-05-02 | 2022-05-04 | 4SS | 148d |  | día 1036 | día 1038 | 900 |
| 13 | 1.1.2.2 | MONTAJE Y DESMONTAJE DE AULAS PREFABRICADAS EXISTENTES | 4d | 2022-05-03 | 2022-05-07 | 10SS | 145d |  | día 1037 | día 1041 | 1860 |
| 14 | 1.1.3 | **MEDIDAS DE MITIGACION AMBIENTAL** | 23d | 2022-05-02 | 2022-05-25 |  | 127d |  |  |  |  |
| 15 | 1.1.3.1 | MITIGACIÓN AMBIENTAL Y MITIGACIÓN DE RIESGO | 23d | 2022-05-02 | 2022-05-25 | 4SS | 127d |  | día 1036 | día 1059 | 10980 |
| 16 | 1.1.4 | **TRABAJOS PRELIMINARES** | 6d | 2022-05-07 | 2022-05-13 |  | 37d | 0d |  |  |  |
| 17 | 1.1.4.1 | NIVELACION, TRAZO Y REPLANTEO PRELIMINAR | 6d | 2022-05-07 | 2022-05-13 | 9 | 37d | 0d | día 1041 | día 1047 | 2820 |
| 18 | 1.1.4.2 | LIMPIEZA PERMANENTE Y FINAL DE LA OBRA | 6d | 2022-05-07 | 2022-05-13 | 17SS | 139d |  | día 1041 | día 1047 | 2820 |
| 19 | 1.1.5 | **DESMONTAJES** | 7d | 2022-05-03 | 2022-05-10 |  | 142d |  |  |  |  |
| 20 | 1.1.5.1 | DESMONTAJE DE PUERTAS | 2d | 2022-05-03 | 2022-05-05 | 10SS | 147d |  | día 1037 | día 1039 | 900 |
| 21 | 1.1.5.2 | DESMONTAJE DE VENTANAS | 2d | 2022-05-03 | 2022-05-05 | 10SS | 147d |  | día 1037 | día 1039 | 900 |
| 22 | 1.1.5.3 | DESMONTAJE TECHO DE ETERNIT/CALAMINA | 3d | 2022-05-03 | 2022-05-06 | 10SS | 146d |  | día 1037 | día 1040 | 1380 |
| 23 | 1.1.5.4 | DESMONTAJE DE APARATOS SANITARIOS | 3d | 2022-05-07 | 2022-05-10 | 16SS | 141d | 0d | día 1041 | día 1044 | 1380 |
| 24 | 1.1.6 | **DEMOLICIONES** | 4d | 2022-05-07 | 2022-05-11 |  | 141d |  |  |  |  |
| 25 | 1.1.6.1 | DEMOLICION DE PISO DE CONCRETO INC.F.P. | 4d | 2022-05-07 | 2022-05-11 | 23SS | 141d | 0d | día 1041 | día 1045 | 1860 |
| 26 | 1.1.6.2 | DEMOLICION DE VEREDAS EXISTENTES | 4d | 2022-05-07 | 2022-05-11 | 25SS | 141d | 0d | día 1041 | día 1045 | 1860 |
| 27 | 1.1.6.3 | DEMOLICION DE MUROS DE LADRILLO | 3d | 2022-05-07 | 2022-05-10 | 26SS | 142d |  | día 1041 | día 1044 | 1380 |
| 28 | 1.1.6.4 | DEMOLICION DE CIMIENTOS | 4d | 2022-05-07 | 2022-05-11 | 26SS | 141d | 1d | día 1041 | día 1045 | 1860 |

| ID | WBS | Task | Duration | Start | Finish | Predecessors | Total slack | Free slack | Constraint | Comienzo de Tarea | Fin de Tarea | Días Calendarios |
| --- | --- | --- | --- | --- | --- | --- | --- | --- | --- | --- | --- | --- |
| 29 | 1.2 | **ESTRUCTURAS** | 65d | 2022-05-08 | 2022-07-12 |  | 37d |  |  |  |  |  |
| 30 | 1.2.1 | **MOVIMIENTO DE TIERRAS** | 9d | 2022-05-08 | 2022-05-17 |  | 37d |  |  |  |  |  |
| 31 | 1.2.1.1 | **CORTES Y EXCAVACIONES** | 9d | 2022-05-08 | 2022-05-17 |  | 37d |  |  |  |  |  |
| 32 | 1.2.1.1.1 | EXCAV. ZANJAS PARA CIMIENTO Y ZAPATAS | 7d | 2022-05-08 | 2022-05-15 | 17SS+1d | 37d | 0d |  | día 1042 | día 1049 | 3300 |
| 33 | 1.2.1.1.2 | EXCAVACION PARA CUNETAS | 3d | 2022-05-08 | 2022-05-11 | 34SS | 141d |  |  | día 1042 | día 1045 | 1380 |
| 34 | 1.2.1.1.3 | EXCAVACIÓN MANUAL PARA VEREDAS ,RAMPAS Y LOSAS | 5d | 2022-05-08 | 2022-05-13 | 32SS | 135d | 0d |  | día 1042 | día 1047 | 2340 |
| 35 | 1.2.1.1.4 | EXCAVACIÓN MANUAL PARA VEREDAS ,RAMPAS Y LOSAS | 4d | 2022-05-13 | 2022-05-17 | 34 | 135d |  |  | día 1047 | día 1051 | 1860 |
| 36 | 1.2.1.1.5 | EXCAVACION DE MATERIAL CONTAMINADO H=0.10 | 5d | 2022-05-09 | 2022-05-14 | 37SS+1d | 138d |  |  | día 1043 | día 1048 | 2340 |
| 37 | 1.2.1.2 | **EXPLANACIONES (CORTE Y NIVELACION)** | 4d | 2022-05-08 | 2022-05-12 |  | 140d | 0d |  | día 0 | día 1 | 420 |
| 38 | 1.2.1.2.1 | CORTE PARA NIVELACION DE TERRENO | 4d | 2022-05-08 | 2022-05-12 | 28SS, 42SS | 140d | 0d |  | día 1042 | día 1046 | 1860 |
| 39 | 1.2.1.2.2 | RELLENO CON MATERIAL DE PRESTAMO PARA NIVELACION DE TERRENO | 3d | 2022-05-08 | 2022-05-11 | 40SS | 141d |  | finish no earlier than 2019-07-04 | día 1042 | día 1045 | 1380 |
| 40 | 1.2.1.2.3 | RELLENO CON MATERIAL PROPIO PARA NIVELACION DE TERRENO | 4d | 2022-05-08 | 2022-05-12 | 38SS | 140d | 0d | finish no earlier than 2019-07-14 | día 1042 | día 1046 | 1860 |
| 41 | 1.2.1.3 | **RELLENOS** | 6d | 2022-05-08 | 2022-05-14 |  | 37d |  |  | día 0 | día 1 | 420 |
| 42 | 1.2.1.3.1 | RELLENO COMPACTADO C/EQUIPO MAT/PROPIO | 5d | 2022-05-08 | 2022-05-13 | 32SS | 37d | 0d | finish no earlier than 2019-07-19 | día 1042 | día 1047 | 2340 |
| 43 | 1.2.1.3.2 | RELLENO COMPACTADO C/EQUIPO MAT/PRESTAMO AFIRMADO | 6d | 2022-05-08 | 2022-05-14 | 42SS | 138d |  | finish no earlier than 2019-07-20 | día 1042 | día 1048 | 2820 |
| 44 | 1.2.1.3.3 | RELLENO COMPACTADO C/EQUIPO MATERIAL PRESTAMO AFIRMADO PARA CUNETAS | 3d | 2022-05-08 | 2022-05-11 | 42SS | 141d |  |  | día 1042 | día 1045 | 1380 |
| 45 | 1.2.1.3.4 | RELLENO CON MATERIAL PROPIO-PARA PISO | 3d | 2022-05-08 | 2022-05-11 | 42SS | 141d |  |  | día 1042 | día 1045 | 1380 |
| 46 | 1.2.1.3.5 | RELLENO CON MATERIAL DE PRESTAMO -PARA PISO | 3d | 2022-05-08 | 2022-05-11 | 42SS | 141d |  |  | día 1042 | día 1045 | 1380 |
| 47 | 1.2.1.4 | **CONFORMACION, NIVELACION Y REFINE** | 3d | 2022-05-13 | 2022-05-16 |  | 37d |  |  | día 0 | día 1 | 420 |
| 48 | 1.2.1.4.1 | NIVELACIÓN DE TERRENO Y COMPACTACION | 3d | 2022-05-13 | 2022-05-16 | 42 | 37d | 0d |  | día 1047 | día 1050 | 1380 |
| 49 | 1.2.2 | **OBRAS DE CONCRETO SIMPLE** | 18d | 2022-05-16 | 2022-06-03 |  | 37d |  |  |  |  |  |
| 50 | 1.2.2.1 | **SOLADO** | 3d | 2022-05-16 | 2022-05-19 |  | 37d |  |  |  |  |  |
| 51 | 1.2.2.1.1 | SOLADO PARA VIGA DE CIMENTACION e=4", 1:12 CEM/HORM | 3d | 2022-05-16 | 2022-05-19 | 48 | 37d | 0d |  | día 1050 | día 1053 | 1380 |
| 52 | 1.2.2.1.2 | SOLADO PARA ZAPATAS e=4", 1:12 CEM/HORM | 2d | 2022-05-16 | 2022-05-18 | 51SS | 134d |  |  | día 1050 | día 1052 | 900 |

| ID | WBS | Task | Duration | Start | Finish | Predecessors | Total slack | Free slack | Comienzo de Tarea | Fin de Tarea | Días Calendarios |
| --- | --- | --- | --- | --- | --- | --- | --- | --- | --- | --- | --- |
| 53 | 1.2.2.2 | **FALSO PISO** | 7d | 2022-05-26 | 2022-06-02 |  | 83d |  |  |  |  |
| 54 | 1.2.2.2.1 | FALSO PISO MEZCLA 1:8 e=4" | 7d | 2022-05-26 | 2022-06-02 | 56, 188SS | 83d | 0d | día 1060 | día 1067 | 3300 |
| 55 | 1.2.2.3 | **CIMIENTOS** | 7d | 2022-05-19 | 2022-05-26 |  | 37d | 0d |  |  |  |
| 56 | 1.2.2.3.1 | CIMIENTO CORRIDO 1:10 + 30 % P.G. f'c >=100Kg/cm2 | 7d | 2022-05-19 | 2022-05-26 | 51 | 37d | 0d | día 1053 | día 1060 | 3300 |
| 57 | 1.2.2.4 | **CUNETAS** | 8d | 2022-05-26 | 2022-06-03 |  | 116d |  |  |  |  |
| 58 | 1.2.2.4.1 | CUNETAS- CONCRETO f'c=175 kg/cm2 | 7d | 2022-05-27 | 2022-06-03 | 59SS+1d | 116d | 0d | día 1061 | día 1068 | 3300 |
| 59 | 1.2.2.4.2 | CUNETAS-ENCOFRADO Y DESENCOFRADO | 7d | 2022-05-26 | 2022-06-02 | 55 | 116d | 0d | día 1060 | día 1067 | 3300 |
| 60 | 1.2.2.4.3 | ACERO CORRUGADO fy=4200 kg/cm2 GRADO 60 | 7d | 2022-05-26 | 2022-06-02 | 59SS | 119d |  | día 1060 | día 1067 | 3300 |
| 61 | 1.2.3 | **OBRAS DE CONCRETO ARMADO** | 47d | 2022-05-26 | 2022-07-12 |  | 37d |  |  |  |  |
| 62 | 1.2.3.1 | **SOBRECIMIENTOS REFORZADOS** | 15d | 2022-05-26 | 2022-06-10 |  | 37d |  |  |  |  |
| 63 | 1.2.3.1.1 | SOBRECIMIENTO- CONCRETO f'c=175 kg/cm2 | 10d | 2022-05-31 | 2022-06-10 | 65SS | 37d | 0d | día 1065 | día 1075 | 4740 |
| 64 | 1.2.3.1.2 | SOBRECIMIENTO-ENCOFRADO Y DESENCOFRADO | 10d | 2022-05-26 | 2022-06-05 | 56 | 37d | 0d | día 1060 | día 1070 | 4740 |
| 65 | 1.2.3.1.3 | ACERO DE REFUERZO F'y=4200 kg/cm2 | 10d | 2022-05-31 | 2022-06-10 | 64SS+5d | 37d | 0d | día 1065 | día 1075 | 4740 |
| 66 | 1.2.3.2 | **ZAPATAS** | 12d | 2022-05-31 | 2022-06-12 |  | 104d |  |  |  |  |
| 67 | 1.2.3.2.1 | ZAPATAS, CONCRETO f'c=210 kg/cm² | 9d | 2022-06-03 | 2022-06-12 | 68SS+3d | 109d |  | día 1068 | día 1077 | 4260 |
| 68 | 1.2.3.2.2 | ZAPATAS, ACERO Fy=4200 kg/cm² | 10d | 2022-05-31 | 2022-06-10 | 65SS | 104d | 0d | día 1065 | día 1075 | 4740 |
| 69 | 1.2.3.3 | **VIGAS DE CIMENTACION** | 17d | 2022-05-31 | 2022-06-17 |  | 104d |  |  |  |  |
| 70 | 1.2.3.3.1 | VIGAS DE CIMENTACION, CONCRETO f'c=210 kg/cm² | 14d | 2022-06-03 | 2022-06-17 | 71SS+3d | 104d |  | día 1068 | día 1082 | 6660 |
| 71 | 1.2.3.3.2 | ENCOFRADO Y DESENCOFRADO PARA VIGAS DE CIMENTACION | 14d | 2022-05-31 | 2022-06-14 | 68SS | 104d | 0d | día 1065 | día 1079 | 6660 |
| 72 | 1.2.3.3.3 | VIGAS DE CIMENTACION, ACERO Fy=4,200 kg/cm² | 14d | 2022-06-02 | 2022-06-16 | 68SS+2d | 105d |  | día 1067 | día 1081 | 6660 |
| 73 | 1.2.3.4 | **COLUMNAS** | 17d | 2022-06-03 | 2022-06-20 |  | 79d |  |  |  |  |
| 74 | 1.2.3.4.1 | COLUMNAS, CONCRETO f'c=210 kg/cm² | 12d | 2022-06-05 | 2022-06-17 | 75SS+2d | 104d |  | día 1070 | día 1082 | 5700 |
| 75 | 1.2.3.4.2 | COLUMNAS, ENCOFRADO Y DESENCOFRADO | 16d | 2022-06-03 | 2022-06-19 | 65SS+3d | 79d | 0d | día 1068 | día 1084 | 7620 |
| 76 | 1.2.3.4.3 | COLUMNAS, ACERO Fy=4200 kg/cm² | 16d | 2022-06-04 | 2022-06-20 | 75SS+1d | 79d | 0d | día 1069 | día 1085 | 7620 |

| ID | WBS | Task | Duration | Start | Finish | Predecessors | Total slack | Free slack | Comienzo de Tarea | Fin de Tarea | Días Calendarios |
| --- | --- | --- | --- | --- | --- | --- | --- | --- | --- | --- | --- |
| 77 | 1.2.3.5 | **VIGAS** | 18d | 2022-06-20 | 2022-07-08 |  | 83d |  |  |  |  |
| 78 | 1.2.3.5.1 | VIGAS, CONCRETO f'c=210 kg/cm² | 13d | 2022-06-20 | 2022-07-03 | 76 | 83d | 0d | día 1085 | día 1098 | 6180 |
| 79 | 1.2.3.5.2 | VIGAS, ENCOFRADO Y DESENCOFRADO | 15d | 2022-06-21 | 2022-07-06 | 78SS+1d | 83d | 0d | día 1086 | día 1101 | 7140 |
| 80 | 1.2.3.5.3 | VIGAS, ACERO Fy=4200 kg/cm² | 15d | 2022-06-23 | 2022-07-08 | 79SS+2d | 83d |  | día 1088 | día 1103 | 7140 |
| 81 | 1.2.3.6 | **LOSA ALIGERADA** | 22d | 2022-06-20 | 2022-07-12 |  | 79d |  |  |  |  |
| 82 | 1.2.3.6.1 | LOSA ALIGERADA, CONCRETO f'c=210 kg/cm² | 18d | 2022-06-24 | 2022-07-12 | 85SS+1d | 79d |  | día 1089 | día 1107 | 8580 |
| 83 | 1.2.3.6.2 | LOSA ALIGERADA, ENCOFRADO Y DESENCOFRADO | 18d | 2022-06-20 | 2022-07-08 | 76 | 79d | 0d | día 1085 | día 1103 | 8580 |
| 84 | 1.2.3.6.3 | LOSA ALIGERADA, ACERO Fy=4,200 kg/cm² | 18d | 2022-06-22 | 2022-07-10 | 83SS+2d | 81d |  | día 1087 | día 1105 | 8580 |
| 85 | 1.2.3.6.4 | LOSA ALIGERADA, LADRILLO HUECO 15 x 30 x 30 | 18d | 2022-06-23 | 2022-07-11 | 83SS+3d | 79d | 0d | día 1088 | día 1106 | 8580 |
| 86 | 1.2.3.7 | **COLUMNETAS Y SOLERAS** | 12d | 2022-06-10 | 2022-06-22 |  | 95d |  |  |  |  |
| 87 | 1.2.3.7.1 | CONCRETO f'c=175 kg/cm2 PARA COLUMNETA | 10d | 2022-06-11 | 2022-06-21 | 88SS+1d | 100d |  | día 1076 | día 1086 | 4740 |
| 88 | 1.2.3.7.2 | ENCOFRADO Y DESENCOFRADO PARA COLUMNETAS | 10d | 2022-06-10 | 2022-06-20 | 63 | 95d | 0d | día 1075 | día 1085 | 4740 |
| 89 | 1.2.3.7.3 | CONCRETO f'c=175 kg/cm2 PARA VIGAS DE CONFINAMIENTO | 10d | 2022-06-12 | 2022-06-22 | 88SS+2d | 99d |  | día 1077 | día 1087 | 4740 |
| 90 | 1.2.3.7.4 | ENCOFRADO Y DESENCOFRADO PARA VIGAS DE CONFINAMIENTO | 10d | 2022-06-11 | 2022-06-21 | 88SS+1d | 100d |  | día 1076 | día 1086 | 4740 |
| 91 | 1.2.3.7.5 | ACERO DE REFUERZO F'y=4200 kg/cm2 | 10d | 2022-06-10 | 2022-06-20 | 88SS | 95d | 0d | día 1075 | día 1085 | 4740 |
| 92 | 1.2.3.8 | **MESA PARA BAÑOS.** | 8d | 2022-05-26 | 2022-06-03 |  | 115d |  | día 0 | día 1 | 420 |
| 93 | 1.2.3.8.1 | MESA DE CONCRETO PARA LAVATORIO (01 POZA) | 4d | 2022-05-30 | 2022-06-03 | 94 | 115d | 0d | día 1064 | día 1068 | 1860 |
| 94 | 1.2.3.8.2 | ENCOFRADO Y DESENCOFRADO PARA MESA DE CONCRETO | 4d | 2022-05-26 | 2022-05-30 | 55 | 115d | 0d | día 1060 | día 1064 | 1860 |
| 95 | 1.2.3.8.3 | ACERO DE REFUERZO F'y=4200 kg/cm2 PARA MESA DE CONCRETO | 4d | 2022-05-26 | 2022-05-30 | 94SS | 122d |  | día 1060 | día 1064 | 1860 |
| 96 | 1.2.3.9 | **CISTERNA** | 10d | 2022-06-10 | 2022-06-20 |  | 95d |  |  |  |  |
| 97 | 1.2.3.9.1 | CISTERNA, CONCRETO f'c=210 kg/cm² | 7d | 2022-06-13 | 2022-06-20 | 99SS+2d | 101d |  | día 1078 | día 1085 | 3300 |
| 98 | 1.2.3.9.2 | CISTERNA, ENCOFRADO Y DESENCOFRADO | 7d | 2022-06-10 | 2022-06-17 | 91SS | 95d | 0d | día 1075 | día 1082 | 3300 |
| 99 | 1.2.3.9.3 | ACERO DE REFUERZO F'y=4200 kg/cm2 | 7d | 2022-06-11 | 2022-06-18 | 98SS+1d | 95d | 0d | día 1076 | día 1083 | 3300 |
| 100 | 1.2.3.10 | **TANQUE ELEVADO** | 15d | 2022-06-11 | 2022-06-26 |  | 95d |  |  |  |  |
| 101 | 1.2.3.10.1 | TANQUES ELEVADOS.- CONCRETO 210 kg/cm2 | 13d | 2022-06-13 | 2022-06-26 | 103SS+1d | 95d |  | día 1078 | día 1091 | 6180 |
| 102 | 1.2.3.10.2 | TANQUES ELEVADOS.- ENCOFRADO Y DESENCOFR | 13d | 2022-06-11 | 2022-06-24 | 99SS | 95d | 0d | día 1076 | día 1089 | 6180 |
| 103 | 1.2.3.10.3 | ACERO DE REFUERZO F'y=4200 kg/cm2 | 13d | 2022-06-12 | 2022-06-25 | 102SS+1d | 95d | 0d | día 1077 | día 1090 | 6180 |

| ID | WBS | Task | Duration | Start | Finish | Predecessors | Total slack | Free slack | Comienzo de Tarea | Fin de Tarea | Días Calendarios |
| --- | --- | --- | --- | --- | --- | --- | --- | --- | --- | --- | --- |
| 104 | 1.2.4 | **FLETE TERRESTRE ESTUCTURAS** | 30d | 2022-06-05 | 2022-07-05 |  | 86d |  |  |  |  |
| 105 | 1.2.4.1 | FLETE TERRESTRE. | 30d | 2022-06-05 | 2022-07-05 | 64 | 86d |  | día 1070 | día 1100 | 14340 |
| 106 | 1.3 | **ARQUITECTURA** | 82d | 2022-06-02 | 2022-08-23 |  | 37d |  |  |  |  |
| 107 | 1.3.1 | **MUROS Y TABIQUES DE ALBAÑILERIA** | 20d | 2022-06-10 | 2022-06-30 |  | 37d | 0d |  |  |  |
| 108 | 1.3.1.1 | MURO DE LADRILLO KK TIPO IV CABEZA M:1:1:4 E=1.5 cm | 20d | 2022-06-10 | 2022-06-30 | 63 | 37d | 0d | día 1075 | día 1095 | 9540 |
| 109 | 1.3.1.2 | MURO DE LADRILLO KK TIPO IV SOGA M:1:1:4 E=1.5 cm | 20d | 2022-06-10 | 2022-06-30 | 108SS | 37d | 0d | día 1075 | día 1095 | 9540 |
| 110 | 1.3.1.3 | ALAMBRE # 8 REFUERZO HORIZONTAL EN MUROS | 20d | 2022-06-10 | 2022-06-30 | 109SS | 37d | 0d | día 1075 | día 1095 | 9540 |
| 111 | 1.3.2 | **REVOQUES Y REVESTIMIENTOS** | 47d | 2022-07-07 | 2022-08-23 |  | 37d |  |  |  |  |
| 112 | 1.3.2.1 | TARRAJEO PRIMARIO PARA RECIBIR ENCHAPES | 20d | 2022-07-07 | 2022-07-27 | 110FS+7d | 52d | 0d | día 1102 | día 1122 | 9540 |
| 113 | 1.3.2.2 | TARRAJEO EN MURO: INTERIOR Y EXTERIOR | 20d | 2022-07-07 | 2022-07-27 | 110FS+7d | 61d | 0d | día 1102 | día 1122 | 9540 |
| 114 | 1.3.2.3 | TARRAJEO DE COLUMNAS | 20d | 2022-07-07 | 2022-07-27 | 110FS+7d | 37d | 0d | día 1102 | día 1122 | 9540 |
| 115 | 1.3.2.4 | TARRAJEO DE VIGAS | 20d | 2022-07-14 | 2022-08-03 | 114SS+7d | 37d | 0d | día 1109 | día 1129 | 9540 |
| 116 | 1.3.2.5 | VESTIDURA DE DERRAMES | 20d | 2022-08-03 | 2022-08-23 | 115 | 37d |  | día 1129 | día 1149 | 9540 |
| 117 | 1.3.2.6 | BRUÑAS 1 x 1 cm | 20d | 2022-07-10 | 2022-07-30 | 113SS+3d | 61d |  | día 1105 | día 1125 | 9540 |
| 118 | 1.3.3 | **CIELO RASO** | 30d | 2022-07-09 | 2022-08-08 |  | 52d |  |  |  |  |
| 119 | 1.3.3.1 | CIELO RASO CON MEZCLA C:A 1:5 | 30d | 2022-07-09 | 2022-08-08 | 112SS+2d | 52d | 0d | día 1104 | día 1134 | 14340 |
| 120 | 1.3.3.2 | FALSO CIELO RASO DE YESO GYPLAC | 11d | 2022-07-14 | 2022-07-25 | 115SS | 51d | 0d | día 1109 | día 1120 | 5220 |
| 121 | 1.3.4 | **PISOS Y PAVIMENTOS** | 57d | 2022-06-02 | 2022-07-29 |  | 62d |  |  |  |  |
| 122 | 1.3.4.1 | PISO DE CERAMICO 30x30cm ANTIDESLIZANTE Y DE ALTO TRANSITO | 13d | 2022-07-14 | 2022-07-27 | 120SS | 51d | 0d | día 1109 | día 1122 | 6180 |
| 123 | 1.3.4.2 | CONCRETO F'c=175 kg/cm2, PARA LOSA E=0.15m | 6d | 2022-07-07 | 2022-07-13 | 112SS | 64d | 0d | día 1102 | día 1108 | 2820 |
| 124 | 1.3.4.3 | VEREDA DE CONCRETO f'c= 175 kg/cm2, INCL. ACABADO Y BRUÑADO | 12d | 2022-06-14 | 2022-06-26 | 126 | 95d |  | día 1079 | día 1091 | 5700 |
| 125 | 1.3.4.4 | RAMPA DE CONCRETO 175 kg/cm2 E=4" BRUÑADO S/DISEÑO | 12d | 2022-06-14 | 2022-06-26 | 126 | 95d |  | día 1079 | día 1091 | 5700 |
| 126 | 1.3.4.5 | VEREDAS,PATIOS Y PLATAFORMAS- ENCOFRADO Y DESENCOFRADO | 12d | 2022-06-02 | 2022-06-14 | 54 | 95d | 0d | día 1067 | día 1079 | 5700 |
| 127 | 1.3.4.6 | CONTRAPISO DE 40 mm PARA RECIBIR PISO CERAMICO | 14d | 2022-07-15 | 2022-07-29 | 122SS+1d | 51d | 0d | día 1110 | día 1124 | 6660 |

| ID | WBS | Task | Duration | Start | Finish | Predecessors | Total slack | Free slack | Comienzo de Tarea | Fin de Tarea | Días Calendarios |
| --- | --- | --- | --- | --- | --- | --- | --- | --- | --- | --- | --- |
| 128 | 1.3.5 | **CONTRAZOCALOS** | 50d | 2022-06-03 | 2022-07-23 |  | 68d |  |  |  |  |
| 129 | 1.3.5.1 | CONTRAZOCALO CERAMICO H= 0.10m | 7d | 2022-07-16 | 2022-07-23 | 127SS+1d | 68d |  | día 1111 | día 1118 | 3300 |
| 130 | 1.3.5.2 | CONTR. S/COLOREAR H=20 cm MZ 1:2 e=1.5 cm | 7d | 2022-07-15 | 2022-07-22 | 127SS | 69d |  | día 1110 | día 1117 | 3300 |
| 131 | 1.3.5.3 | CONTRAZOCALO DE CEMENTO PULIDO CON ENDURECEDOR H=20 cm | 7d | 2022-07-15 | 2022-07-22 | 127SS | 69d |  | día 1110 | día 1117 | 3300 |
| 132 | 1.3.5.4 | REVESTIMIENTO CERAMICO COLOR 20X30 MESA DE CONCRETO | 3d | 2022-06-03 | 2022-06-06 | 93 | 115d |  | día 1068 | día 1071 | 1380 |
| 133 | 1.3.6 | **ZOCALOS** | 7d | 2022-07-15 | 2022-07-22 |  | 51d |  |  |  |  |
| 134 | 1.3.6.1 | ZOCALO DE CERAMICO 30x30 | 7d | 2022-07-15 | 2022-07-22 | 127SS | 51d | 0d | día 1110 | día 1117 | 3300 |
| 135 | 1.3.6.2 | ZOCALO DE CERAMICO 30x20 | 7d | 2022-07-15 | 2022-07-22 | 127SS | 54d | 0d | día 1110 | día 1117 | 3300 |
| 136 | 1.3.7 | **COBERTURA (CUBIERTA)** | 7d | 2022-07-09 | 2022-07-16 |  | 75d |  |  |  |  |
| 137 | 1.3.7.1 | IMPERMEABILIZACION DE TECHOS CON PINTURA ASFALTICA | 7d | 2022-07-09 | 2022-07-16 | 138SS | 75d |  | día 1104 | día 1111 | 3300 |
| 138 | 1.3.7.2 | CANALETA EVAC AGUAS PLUVIALES C/ PLANCHA ACERO GALV. TIPO CALAMINA | 7d | 2022-07-09 | 2022-07-16 | 119SS | 75d | 0d | día 1104 | día 1111 | 3300 |
| 139 | 1.3.8 | **CARPINTERIA DE MADERA** | 18d | 2022-07-22 | 2022-08-09 |  | 51d |  |  |  |  |
| 140 | 1.3.8.1 | PUERTA MADERA MACIZA C/ SOBREVENTANA DE MADERA | 7d | 2022-07-22 | 2022-07-29 | 134 | 62d |  | día 1117 | día 1124 | 3300 |
| 141 | 1.3.8.2 | PUERTA DE MADERA MACIZA CON BARNIZ MARINO ,DOS MANOS | 7d | 2022-07-22 | 2022-07-29 | 134 | 62d |  | día 1117 | día 1124 | 3300 |
| 142 | 1.3.8.3 | PUERTA DE PLANCHA DE MALAMINE DE 18 mm | 7d | 2022-07-22 | 2022-07-29 | 134 | 51d | 0d | día 1117 | día 1124 | 3300 |
| 143 | 1.3.8.4 | VENTANA DE MADERA SIST. BATIENTE C/VIDRIO TEMPLADO e=6mm Y LAMINA DE SEG | 7d | 2022-07-29 | 2022-08-05 | 142 | 51d | 0d | día 1124 | día 1131 | 3300 |
| 144 | 1.3.8.5 | TABIQUE DIVISORIO DE MELAMINE DE 18 mm | 7d | 2022-08-02 | 2022-08-09 | 143SS+4d | 51d |  | día 1128 | día 1135 | 3300 |
| 145 | 1.3.8.6 | MAMPARA DE VIDRIO 6MM DE 1 HOJA | 7d | 2022-07-30 | 2022-08-06 | 143SS+1d | 54d |  | día 1125 | día 1132 | 3300 |
| 146 | 1.3.8.7 | TICERO DE MADERA BARNIZADO DE 3" x 4" de 4.50 m | 7d | 2022-07-22 | 2022-07-29 | 142SS | 62d |  | día 1117 | día 1124 | 3300 |
| 147 | 1.3.9 | **CARPINTERIA METALICA Y HERRERIA** | 9d | 2022-07-22 | 2022-07-31 |  | 53d |  |  |  |  |
| 148 | 1.3.9.1 | PUERTA METÁLICA C/PLANCHA NERVADA DE 1 HOJA | 8d | 2022-07-22 | 2022-07-30 | 142SS | 53d | 0d | día 1117 | día 1125 | 3780 |
| 149 | 1.3.9.2 | VENTANA ALTA FIJA DE FIERRO | 8d | 2022-07-22 | 2022-07-30 | 148SS | 53d | 0d | día 1117 | día 1125 | 3780 |
| 150 | 1.3.9.3 | GANCHO DOBLE PARA SS.HH. DE DISCAPACITADOS | 8d | 2022-07-23 | 2022-07-31 | 148SS+1d | 60d |  | día 1118 | día 1126 | 3780 |
| 151 | 1.3.9.4 | REJILLA DE FE REMOVIBLE PARA CANALETA | 8d | 2022-07-23 | 2022-07-31 | 148SS+1d | 60d |  | día 1118 | día 1126 | 3780 |
| 152 | 1.3.9.5 | ESCALERA METALICA TIPO GATO a = 0.61 m | 8d | 2022-07-22 | 2022-07-30 | 149SS | 61d |  | día 1117 | día 1125 | 3780 |
| 153 | 1.3.9.6 | ESCALERA DE GATO DE ALUMNINIO PARA CISTERNA | 8d | 2022-07-22 | 2022-07-30 | 149SS | 61d |  | día 1117 | día 1125 | 3780 |
| 154 | 1.3.9.7 | TAPA METALICA EN CISTERNA, INC. ALDABA Y PINTURA | 8d | 2022-07-22 | 2022-07-30 | 149SS | 61d |  | día 1117 | día 1125 | 3780 |

| ID | WBS | Task | Duration | Start | Finish | Predecessors | Total slack | Free slack | Comienzo de Tarea | Fin de Tarea | Días Calendarios |
| --- | --- | --- | --- | --- | --- | --- | --- | --- | --- | --- | --- |
| 155 | 1.3.10 | **CERRAJERIA** | 8d | 2022-07-22 | 2022-07-30 |  | 61d |  |  |  |  |
| 156 | 1.3.10.1 | BISAGRA METALICA DE 2.5" EN VENTANA | 8d | 2022-07-22 | 2022-07-30 | 149SS | 61d |  | día 1117 | día 1125 | 3780 |
| 157 | 1.3.10.2 | CERRADURA METALICA TRES GOLPES O SIMILAR | 8d | 2022-07-22 | 2022-07-30 | 149SS | 61d |  | día 1117 | día 1125 | 3780 |
| 158 | 1.3.10.3 | CERRADURA TIPO MANIJA DE ACERO INOX. P/PUERTA | 8d | 2022-07-22 | 2022-07-30 | 149SS | 61d |  | día 1117 | día 1125 | 3780 |
| 159 | 1.3.10.4 | CERROJO "SAPITO" SEGURIDAD BAT.VENTANA | 8d | 2022-07-22 | 2022-07-30 | 148SS | 61d |  | día 1117 | día 1125 | 3780 |
| 160 | 1.3.10.5 | CADENA GALVANIZADA DE 1/8",DOS PZA 30CM BATIENTE VENTANA | 8d | 2022-07-22 | 2022-07-30 | 148SS | 61d |  | día 1117 | día 1125 | 3780 |
| 161 | 1.3.11 | **VIDRIOS, CRISTALES Y SIMILARES** | 8d | 2022-07-30 | 2022-08-07 |  | 53d |  |  |  |  |
| 162 | 1.3.11.1 | VIDRIO TEMPLADO e=6mm | 8d | 2022-07-30 | 2022-08-07 | 149 | 53d | 0d | día 1125 | día 1133 | 3780 |
| 163 | 1.3.11.2 | ESPEJO BISELADO | 1d | 2022-07-30 | 2022-07-31 | 162SS | 60d |  | día 1125 | día 1126 | 420 |
| 164 | 1.3.12 | **PINTURA** | 24d | 2022-07-13 | 2022-08-06 |  | 54d |  |  |  |  |
| 165 | 1.3.12.1 | PINTURA LATEX 2 MANOS EN CIELO RASO Y VIGAS | 20d | 2022-07-17 | 2022-08-06 | 135SS+2d | 54d | 0d | día 1112 | día 1132 | 9540 |
| 166 | 1.3.12.2 | PINTURA LATEX 2 MANOS EN MUROS Y COLUMNA | 20d | 2022-07-17 | 2022-08-06 | 165SS | 54d | 0d | día 1112 | día 1132 | 9540 |
| 167 | 1.3.12.3 | PINTURA ANTICORROSIVA Y ESMALTE DOS MANOS CARPINTERIA METÁLICA | 20d | 2022-07-17 | 2022-08-06 | 166SS | 54d | 0d | día 1112 | día 1132 | 9540 |
| 168 | 1.3.12.4 | PINTURA BARNIZ EN CARPINTERIA DE MADERA | 20d | 2022-07-17 | 2022-08-06 | 166SS | 54d |  | día 1112 | día 1132 | 9540 |
| 169 | 1.3.12.5 | PINTURA DEMARCACION DE LOSA DEPORTIVA | 6d | 2022-07-13 | 2022-07-19 | 123 | 64d | 0d | día 1108 | día 1114 | 2820 |
| 170 | 1.3.13 | **JUNTAS** | 58d | 2022-06-03 | 2022-07-31 |  | 60d |  | día 0 | día 1 | 420 |
| 171 | 1.3.13.1 | JUNTA DE DILATACION CON ESPUMA PLASTICA+JEBE MICROPOROSO | 2d | 2022-07-13 | 2022-07-15 | 123 | 76d |  | día 1108 | día 1110 | 900 |
| 172 | 1.3.13.2 | JUNTA DE DILATACION EN MODULO CON TECNOPORT DE e= 3/8'' RELLENO CON POLIUTERANO | 2d | 2022-07-27 | 2022-07-29 | 122 | 60d | 0d | día 1122 | día 1124 | 900 |
| 173 | 1.3.13.3 | JUNTA ASFALTICA E=1" | 2d | 2022-07-29 | 2022-07-31 | 172 | 60d |  | día 1124 | día 1126 | 900 |
| 174 | 1.3.13.4 | JUNTA ELASTOMERICA PARA CUNETAS E=1/2'' | 2d | 2022-06-03 | 2022-06-05 | 58 | 116d |  | día 1068 | día 1070 | 900 |
| 175 | 1.3.14 | **JUEGOS INFANTILES** | 8d | 2022-07-19 | 2022-07-27 |  | 64d |  |  |  |  |
| 176 | 1.3.14.1 | ARCO Y TABLERO FULBITO-BASKET(MET-MAD) | 7d | 2022-07-19 | 2022-07-26 | 169 | 64d | 0d | día 1114 | día 1121 | 3300 |
| 177 | 1.3.14.2 | TUBOS C. VOLEY, INC. RED Y DADOS CONCRETO | 7d | 2022-07-19 | 2022-07-26 | 176SS | 65d |  | día 1114 | día 1121 | 3300 |
| 178 | 1.3.14.3 | PASAMANOS METALICOS L=2.80m (JUEGO INFANTIL) | 8d | 2022-07-19 | 2022-07-27 | 176SS | 64d |  | día 1114 | día 1122 | 3780 |
| 179 | 1.3.14.4 | SUBE Y BAJA METALICO DOBLE CON 06 ASIENTOS | 7d | 2022-07-19 | 2022-07-26 | 176SS | 65d |  | día 1114 | día 1121 | 3300 |
| 180 | 1.3.14.5 | COLUMPIO METALICOS L=3.10m (JUEGO INFANTIL) CON 03 ASIENTO | 7d | 2022-07-19 | 2022-07-26 | 176SS | 65d |  | día 1114 | día 1121 | 3300 |

| ID | WBS | Task | Duration | Start | Finish | Predecessors | Total slack | Free slack | Comienzo de Tarea | Fin de Tarea | Días Calendarios |
| --- | --- | --- | --- | --- | --- | --- | --- | --- | --- | --- | --- |
| 181 | 1.3.15 | **VARIOS, LIMPIEZA Y JARDINERIA** | 4d | 2022-07-17 | 2022-07-21 |  | 70d |  | día 0 | día 1 | 420 |
| 182 | 1.3.15.1 | ASTA DE BANDERA TIPICO | 2d | 2022-07-19 | 2022-07-21 | 169 | 70d |  | día 1114 | día 1116 | 900 |
| 183 | 1.3.15.2 | PLANTAS ORNAMENTALES | 2d | 2022-07-17 | 2022-07-19 | 167SS | 72d |  | día 1112 | día 1114 | 900 |
| 184 | 1.3.16 | **FLETE TERRESTRE** | 30d | 2022-06-10 | 2022-07-10 |  | 81d |  |  |  |  |
| 185 | 1.3.16.1 | FLETE - TERRESTRE. | 30d | 2022-06-10 | 2022-07-10 | 107SS | 81d |  | día 1075 | día 1105 | 14340 |
| 186 | 1.4 | **INSTALACIONES SANITARIAS** | 21d | 2022-05-26 | 2022-06-16 |  | 83d |  |  |  |  |
| 187 | 1.4.1 | **CONEXION A RED EXISTENTE** | 1d | 2022-05-26 | 2022-05-27 |  | 83d | 0d |  |  |  |
| 188 | 1.4.1.1 | EMPALME A RED EXISTENTE, AGUA | 1d | 2022-05-26 | 2022-05-27 | 64SS | 83d | 0d | día 1060 | día 1061 | 420 |
| 189 | 1.4.2 | **APARATOS SANITARIOS Y ACCESORIOS** | 8d | 2022-05-26 | 2022-06-03 |  | 118d |  |  |  |  |
| 190 | 1.4.2.1 | **SUMINISTRO E INSTALACION D/APARATOS SANITARIOS Y ACCESORIOS** | 8d | 2022-05-26 | 2022-06-03 |  | 118d |  |  |  |  |
| 191 | 1.4.2.1.1 | INODORO TANQUE BAJO DE LOSA 1ra CALIDAD ADULTO (NAC. BLANCO) | 7d | 2022-05-26 | 2022-06-02 | 206SS | 119d |  | día 1060 | día 1067 | 3300 |
| 192 | 1.4.2.1.2 | URINARIO DE LOSA TIPO CADET O SIMILAR | 7d | 2022-05-26 | 2022-06-02 | 206SS | 119d |  | día 1060 | día 1067 | 3300 |
| 193 | 1.4.2.1.3 | LAVATORIO DE LOSA TIPO OVALIN C/GRIFERIA AL MUEBLE MANIJA LARGA | 7d | 2022-05-26 | 2022-06-02 | 206SS | 119d |  | día 1060 | día 1067 | 3300 |
| 194 | 1.4.2.1.4 | LAVATORIO DE LOSA TIPO OVALIN INC GRIFERIA TIPO PALANCA P/NIÑOS | 7d | 2022-05-26 | 2022-06-02 | 206SS | 119d |  | día 1060 | día 1067 | 3300 |
| 195 | 1.4.2.1.5 | GRIFERIA DE 1/2" PARA BOTADERO | 2d | 2022-05-27 | 2022-05-29 | 206SS+1d | 123d |  | día 1061 | día 1063 | 900 |
| 196 | 1.4.2.1.6 | LLAVE DE LAVATORIO A LA PARED TEMPORIZADO | 7d | 2022-05-27 | 2022-06-03 | 206SS+1d | 118d |  | día 1061 | día 1068 | 3300 |
| 197 | 1.4.2.1.7 | LLAVE DE DUCHA CON SALIDA CROMADA TIPO ESPAÑOLA | 4d | 2022-05-27 | 2022-05-31 | 206SS+1d | 121d |  | día 1061 | día 1065 | 1860 |
| 198 | 1.4.2.1.8 | PAPELERA DE CERAMICA | 2d | 2022-05-27 | 2022-05-29 | 206SS+1d | 123d |  | día 1061 | día 1063 | 900 |
| 199 | 1.4.2.1.9 | JABONERA DE LOSA CON AGARRADERA | 2d | 2022-05-27 | 2022-05-29 | 206SS+1d | 123d |  | día 1061 | día 1063 | 900 |
| 200 | 1.4.3 | **SISTEMA DE AGUA FRIA** | 10d | 2022-05-26 | 2022-06-05 |  | 83d |  |  |  |  |
| 201 | 1.4.3.1 | **SALIDA DE AGUA FRIA** | 7d | 2022-05-26 | 2022-06-02 |  | 119d |  |  |  |  |
| 202 | 1.4.3.1.1 | SALIDA DE AGUA FRIA.- PVC | 7d | 2022-05-26 | 2022-06-02 | 54SS | 119d |  | día 1060 | día 1067 | 3300 |
| 203 | 1.4.3.2 | **RED DE DISTRIBUCION** | 10d | 2022-05-26 | 2022-06-05 |  | 83d |  |  |  |  |
| 204 | 1.4.3.2.1 | TUBERIA PVC CLASE 10 - 1/2" ROSCADA | 10d | 2022-05-26 | 2022-06-05 | 54SS | 83d | 0d | día 1060 | día 1070 | 4740 |
| 205 | 1.4.3.2.2 | TUBERIA PVC CLASE 10 - 1" ROSCADA | 10d | 2022-05-26 | 2022-06-05 | 54SS | 116d |  | día 1060 | día 1070 | 4740 |
| 206 | 1.4.3.2.3 | TUBERIA PVC CLASE 10 - 3/4" ROSCADA | 10d | 2022-05-26 | 2022-06-05 | 54SS | 116d | 0d | día 1060 | día 1070 | 4740 |

| ID | WBS | Task | Duration | Start | Finish | Predecessors | Total slack | Free slack | Comienzo de Tarea | Fin de Tarea | Días Calendarios |
| --- | --- | --- | --- | --- | --- | --- | --- | --- | --- | --- | --- |
| 207 | 1.4.3.3 | **ACCESORIOS DE RED DE DISTRIBUCION +** | 10d | 2022-05-26 | 2022-06-05 |  | 116d |  |  |  |  |
| 208 | 1.4.3.3.1 | CODO PVC-SAP 1/2" * 90 | 10d | 2022-05-26 | 2022-06-05 | 54SS | 116d |  | día 1060 | día 1070 | 4740 |
| 209 | 1.4.3.3.2 | CODO PVC-SAP 3/4" * 90 | 10d | 2022-05-26 | 2022-06-05 | 54SS | 116d |  | día 1060 | día 1070 | 4740 |
| 210 | 1.4.3.3.3 | CODO PVC-SAP 1" * 90 | 10d | 2022-05-26 | 2022-06-05 | 54SS | 116d |  | día 1060 | día 1070 | 4740 |
| 211 | 1.4.3.3.4 | REDUCCIONES PVC-SAP 1" A 1/2" | 10d | 2022-05-26 | 2022-06-05 | 54SS | 116d |  | día 1060 | día 1070 | 4740 |
| 212 | 1.4.3.3.5 | REDUCCIONES PVC-SAP 3/4" A 1/2" | 10d | 2022-05-26 | 2022-06-05 | 54SS | 116d |  | día 1060 | día 1070 | 4740 |
| 213 | 1.4.3.3.6 | INSTALACION DE ACCESORIOS DE RED DE DISTRIBUCION | 10d | 2022-05-26 | 2022-06-05 | 54SS | 116d |  | día 1060 | día 1070 | 4740 |
| 214 | 1.4.3.4 | **VALVULAS Y LLAVES** | 4d | 2022-05-26 | 2022-05-30 |  | 122d |  |  |  |  |
| 215 | 1.4.3.4.1 | VALVULA DE COMPUERTA DE BRONCE 1/2" | 2d | 2022-05-26 | 2022-05-28 | 54SS | 124d |  | día 1060 | día 1062 | 900 |
| 216 | 1.4.3.4.2 | VALVULA DE COMPUERTA DE BRONCE 3/4" | 4d | 2022-05-26 | 2022-05-30 | 54SS | 122d |  | día 1060 | día 1064 | 1860 |
| 217 | 1.4.3.5 | **VARIOS** | 4d | 2022-05-31 | 2022-06-04 |  | 117d |  |  |  |  |
| 218 | 1.4.3.5.1 | CAJA PARA VALVULA (NICHO DE MAYOLICA) | 4d | 2022-05-31 | 2022-06-04 | 224 | 117d |  | día 1065 | día 1069 | 1860 |
| 219 | 1.4.4 | **DESAGÜE Y VENTILACION** | 14d | 2022-05-26 | 2022-06-09 |  | 105d |  |  |  |  |
| 220 | 1.4.4.1 | **SALIDA DE DESAGUE** | 7d | 2022-05-26 | 2022-06-02 |  | 105d |  |  |  |  |
| 221 | 1.4.4.1.1 | SALIDA DE DESAGUE EN PVC-CP Ø DE 2" | 7d | 2022-05-26 | 2022-06-02 | 54SS | 119d |  | día 1060 | día 1067 | 3300 |
| 222 | 1.4.4.1.2 | SALIDA DE DESAGUE EN PVC-CP Ø DE 2" CON TRAMPA "P" | 7d | 2022-05-26 | 2022-06-02 | 54SS | 119d |  | día 1060 | día 1067 | 3300 |
| 223 | 1.4.4.1.3 | SALIDA DE DESAGUE EN PVC-CP Ø DE 4" | 7d | 2022-05-26 | 2022-06-02 | 54SS | 119d |  | día 1060 | día 1067 | 3300 |
| 224 | 1.4.4.1.4 | CODO PVC SAL 2"X90° | 5d | 2022-05-26 | 2022-05-31 | 54SS | 105d | 0d | día 1060 | día 1065 | 2340 |
| 225 | 1.4.4.2 | **RED DE DERIVACION** | 7d | 2022-06-02 | 2022-06-09 |  | 112d |  |  |  |  |
| 226 | 1.4.4.2.1 | TUBERIA PVC-SAP 2" RED INTERIOR | 7d | 2022-06-02 | 2022-06-09 | 232SS+2d | 112d |  | día 1067 | día 1074 | 3300 |
| 227 | 1.4.4.2.2 | TUBERIA PVC-SAP 4" RED INTERIOR | 7d | 2022-06-02 | 2022-06-09 | 232SS+2d | 112d |  | día 1067 | día 1074 | 3300 |
| 228 | 1.4.4.2.3 | MONTANTE Y/O VENTILACION CON TUBERIA PVC - CP Ø DE 2" | 7d | 2022-06-02 | 2022-06-09 | 232SS+2d | 112d |  | día 1067 | día 1074 | 3300 |
| 229 | 1.4.4.3 | **ACCESORIOS DE LA RED** | 5d | 2022-05-31 | 2022-06-05 |  | 105d |  |  |  |  |
| 230 | 1.4.4.3.1 | SUMIDERO DE BRONCE 2" | 5d | 2022-05-31 | 2022-06-05 | 224 | 116d |  | día 1065 | día 1070 | 2340 |
| 231 | 1.4.4.3.2 | REGISTRO DE BRONCE 2" | 5d | 2022-05-31 | 2022-06-05 | 224 | 105d | 0d | día 1065 | día 1070 | 2340 |
| 232 | 1.4.4.3.3 | REGISTRO DE BRONCE 4" | 5d | 2022-05-31 | 2022-06-05 | 224 | 112d | 0d | día 1065 | día 1070 | 2340 |
| 233 | 1.4.4.3.4 | SOMBRERO VENTILACION PVC DE 2" | 5d | 2022-05-31 | 2022-06-05 | 231SS | 105d | 0d | día 1065 | día 1070 | 2340 |

| ID | WBS | Task | Duration | Start | Finish | Predecessors | Total slack | Free slack | Comienzo de Tarea | Fin de Tarea | Días Calendarios |
| --- | --- | --- | --- | --- | --- | --- | --- | --- | --- | --- | --- |
| 234 | 1.4.4.4 | **CAMARAS DE INSPECCION** | 5d | 2022-05-31 | 2022-06-05 |  | 105d |  |  |  |  |
| 235 | 1.4.4.4.1 | CAJA SUMIDERO (0.20x0.20) C/TAPA REJILLA | 1d | 2022-06-01 | 2022-06-02 | 233SS+1d | 119d |  | día 1066 | día 1067 | 420 |
| 236 | 1.4.4.4.2 | CAJA DE REGISTRO CIEGO DE ALBAÑILERIA 12" x 24" (0.30x0.60) C/ TAPA CONCRETO REFORZADO | 5d | 2022-05-31 | 2022-06-05 | 233SS | 105d | 0d | día 1065 | día 1070 | 2340 |
| 237 | 1.4.5 | **INSTALACIONES ESPECIALES** | 15d | 2022-06-01 | 2022-06-16 |  | 105d |  |  |  |  |
| 238 | 1.4.5.1 | **TUBERIAS Y ACCESORIOS DE TANQUE ELEVADO** | 15d | 2022-06-01 | 2022-06-16 |  | 105d |  |  |  |  |
| 239 | 1.4.5.1.1 | TUBERIA PVC CLASE 10 - 1/2" ROSCADA | 14d | 2022-06-01 | 2022-06-15 | 236SS+1d | 105d | 0d | día 1066 | día 1080 | 6660 |
| 240 | 1.4.5.1.2 | TUBERIA PVC CLASE 10 - 1" ROSCADA | 14d | 2022-06-02 | 2022-06-16 | 239SS+1d | 105d | 0d | día 1067 | día 1081 | 6660 |
| 241 | 1.4.5.1.3 | VENTILACION T.E SAP CLASE 10 - 3" ROSCADA | 14d | 2022-06-02 | 2022-06-16 | 240SS | 105d |  | día 1067 | día 1081 | 6660 |
| 242 | 1.4.5.1.4 | TUBERIA DE LIMPIEZA T.E PVC SAP CLASE 10 - 3" ROSCADA | 14d | 2022-06-02 | 2022-06-16 | 240SS | 105d |  | día 1067 | día 1081 | 6660 |
| 243 | 1.4.5.1.5 | VALVULA DE COMPUERTA DE BRONCE 1 1/4" | 14d | 2022-06-02 | 2022-06-16 | 240SS | 105d |  | día 1067 | día 1081 | 6660 |
| 244 | 1.4.5.1.6 | VALVULA COMPUERTA DE 1" | 14d | 2022-06-02 | 2022-06-16 | 240SS | 105d |  | día 1067 | día 1081 | 6660 |
| 245 | 1.4.5.1.7 | VALVULA CHECK DE BRONCE 1" | 14d | 2022-06-02 | 2022-06-16 | 240SS | 105d |  | día 1067 | día 1081 | 6660 |
| 246 | 1.4.5.1.8 | VALVULA FLOTADORA 1" | 14d | 2022-06-02 | 2022-06-16 | 240SS | 105d |  | día 1067 | día 1081 | 6660 |
| 247 | 1.4.5.1.9 | VALVULA TIPO BOLA 3" | 14d | 2022-06-02 | 2022-06-16 | 240SS | 105d |  | día 1067 | día 1081 | 6660 |
| 248 | 1.4.5.1.10 | VALVULA DE PIE Y CANASTILLA DE 1 1/4" | 14d | 2022-06-02 | 2022-06-16 | 240SS | 105d |  | día 1067 | día 1081 | 6660 |
| 249 | 1.4.5.1.11 | CAJA DE REBOSE C/REJILLA DE FIERRO | 10d | 2022-06-02 | 2022-06-12 | 240SS | 105d | 0d | día 1067 | día 1077 | 4740 |
| 250 | 1.4.5.1.12 | EQUIPO DE BOMBEO, 02 ELECTROBOMBAS 1 HP | 14d | 2022-06-02 | 2022-06-16 | 249SS | 105d |  | día 1067 | día 1081 | 6660 |
| 251 | 1.4.5.1.13 | REBOSE DE CISTERNA DE F°G° 4" | 14d | 2022-06-02 | 2022-06-16 | 240SS | 105d |  | día 1067 | día 1081 | 6660 |
| 252 | 1.4.6 | **FLETE TERRESTRE** | 20d | 2022-05-26 | 2022-06-15 |  | 83d |  |  |  |  |
| 253 | 1.4.6.1 | FLETE TERRESTRE PIURA-MORROPON | 20d | 2022-05-26 | 2022-06-15 | 204SS | 83d | 0d | día 1060 | día 1080 | 9540 |
| 254 | 1.5 | **INSTALACIONES ELECTRICAS** | 67d | 2022-05-02 | 2022-07-08 |  | 83d |  |  |  |  |
| 255 | 1.5.1 | CONEXION A RED EXISTENTE | 1d | 2022-05-26 | 2022-05-27 | 253SS | 125d |  | día 1060 | día 1061 | 420 |
| 256 | 1.5.2 | **SALIDA PARA ALUMBRADO, TOMACORRIENTES, FUERZA Y SEÑALES DEBILES** | 42d | 2022-05-27 | 2022-07-08 |  | 83d |  |  |  |  |
| 257 | 1.5.2.1 | SALIDA DE TECHO (CENTRO DE LUZ) | 40d | 2022-05-27 | 2022-07-06 | 253SS+1d | 85d |  | día 1061 | día 1101 | 19140 |
| 258 | 1.5.2.2 | INTERRUPTOR DE 02 GOLPES | 40d | 2022-05-28 | 2022-07-07 | 253SS+2d | 83d | 0d | día 1062 | día 1102 | 19140 |
| 259 | 1.5.2.3 | SALIDA TOMACORRIENTE DOBLE CON LINEA DE TIERRA | 40d | 2022-05-29 | 2022-07-08 | 258SS+1d | 83d | 0d | día 1063 | día 1103 | 19140 |
| 260 | 1.5.2.4 | SALIDA PARA LUZ DE EMERGENCIA | 40d | 2022-05-29 | 2022-07-08 | 259SS | 83d |  | día 1063 | día 1103 | 19140 |

| ID | WBS | Task | Duration | Start | Finish | Predecessors | Total slack | Free slack | Comienzo de Tarea | Fin de Tarea | Días Calendarios |
| --- | --- | --- | --- | --- | --- | --- | --- | --- | --- | --- | --- |
| 261 | 1.5.3 | **CANALIZACION Y/O TUBERIA** | 40d | 2022-05-29 | 2022-07-08 |  | 83d |  |  |  |  |
| 262 | 1.5.3.1 | TUBERIA PVC-P 20mm | 40d | 2022-05-29 | 2022-07-08 | 259SS | 83d | 0d | día 1063 | día 1103 | 19140 |
| 263 | 1.5.4 | **CAJAS** | 7d | 2022-05-29 | 2022-06-05 |  | 116d |  |  |  |  |
| 264 | 1.5.4.1 | CAJA DE PASE OCTOGONAL CON TAPA CIEGA 100 x 55 MM | 7d | 2022-05-29 | 2022-06-05 | 262SS | 116d |  | día 1063 | día 1070 | 3300 |
| 265 | 1.5.4.2 | CAJA DE PASE F°G° 100X100x50 MM | 7d | 2022-05-29 | 2022-06-05 | 262SS | 116d |  | día 1063 | día 1070 | 3300 |
| 266 | 1.5.5 | **TABLEROS Y CUCHILLAS** | 1d | 2022-05-29 | 2022-05-30 |  | 120d |  |  |  |  |
| 267 | 1.5.5.1 | TABLEROS DE DISTRIBUCION EQUIPADOS E INSTALADOS | 1d | 2022-05-29 | 2022-05-30 | 262SS | 120d | 0d | día 1063 | día 1064 | 420 |
| 268 | 1.5.6 | **INSTALACION DE SISTEMA DE PUESTA A TIERRA** | 3d | 2022-05-29 | 2022-06-01 |  | 120d |  |  |  |  |
| 269 | 1.5.6.1 | POZO PUESTA A TIERRA-2004 P-1 ( R<15 Ohms) | 3d | 2022-05-29 | 2022-06-01 | 267SS | 120d |  | día 1063 | día 1066 | 1380 |
| 270 | 1.5.7 | **ARTEFACTOS** | 7d | 2022-05-30 | 2022-06-06 |  | 115d |  |  |  |  |
| 271 | 1.5.7.1 | LAMPARA TORNADO T2 20W E27 220-240V (FOCO AHORRADOR) | 7d | 2022-05-30 | 2022-06-06 | 262SS+1d | 115d |  | día 1064 | día 1071 | 3300 |
| 272 | 1.5.7.2 | ARTEFACTO TIPO PARA ADOSAR, CON TRE LAMPARA FLUORESCENTE DE 36 W, ALTO FACTOR DE POTENCIA,CON BALASTRO ELECTRONICO CON DIFUSOR ACRILICO SIMILAR AL TIPO GEIUS 1 X 36 W | 7d | 2022-05-30 | 2022-06-06 | 262SS+1d | 115d |  | día 1064 | día 1071 | 3300 |
| 273 | 1.5.7.3 | ARTEFACTO DE ILUMINACION DE EMERGENCIA CON DOS LAMPARAS DE 20W, CON 2 HORAS DE AUTONOMIA | 7d | 2022-05-30 | 2022-06-06 | 262SS+1d | 115d |  | día 1064 | día 1071 | 3300 |
| 274 | 1.5.7.4 | FAROLA JP 250 LAMPARA NA 70W | 7d | 2022-05-30 | 2022-06-06 | 262SS+1d | 115d |  | día 1064 | día 1071 | 3300 |
| 275 | 1.5.7.5 | REFLECTOR SIMILAR TIPO ARAN, LAMP. HIT, SOCKET E40, POTENCIA 1X400W SIMETRICO | 7d | 2022-05-30 | 2022-06-06 | 262SS+1d | 115d |  | día 1064 | día 1071 | 3300 |
| 276 | 1.5.8 | **OTROS** | 7d | 2022-05-02 | 2022-05-09 |  | 130d |  |  |  |  |
| 277 | 1.5.8.1 | CAMPANILLA DE TIMBRE DE 8" CON TRANF 220/12V | 7d | 2022-05-02 | 2022-05-09 |  | 130d | 0d | día 1036 | día 1043 | 3300 |
| 278 | 1.5.8.2 | CAMPANILLA DE TIMBRE DE 2" CON TRANF 220/12V | 7d | 2022-05-02 | 2022-05-09 |  | 143d |  | día 1036 | día 1043 | 3300 |
| 279 | 1.5.8.3 | LLAVE BIPOLAR 2X15A | 7d | 2022-05-02 | 2022-05-09 |  | 143d |  | día 1036 | día 1043 | 3300 |
| 280 | 1.5.8.4 | BUZON CONCRETO DE 1.10 X 1.10 X 0.85 M | 7d | 2022-05-02 | 2022-05-09 |  | 130d | 0d | día 1036 | día 1043 | 3300 |
| 281 | 1.6 | **INSTALACIONES DE COMUNICACION Y RED DE DATOS** | 44d | 2022-05-02 | 2022-06-15 |  | 106d |  |  |  |  |
| 282 | 1.6.1 | **ELECTROBOMBA Y ACCESORIOS** | 20d | 2022-05-02 | 2022-05-22 |  | 130d |  |  |  |  |
| 283 | 1.6.1.1 | ELECTROBOMBA ALTO RENDIMIENTO | 20d | 2022-05-02 | 2022-05-22 | 277SS | 130d |  | día 1036 | día 1056 | 9540 |
| 284 | 1.6.2 | **SALIDA PARA COMUNICACION Y SEÑALES** | 20d | 2022-05-02 | 2022-05-22 |  | 130d |  |  |  |  |
| 285 | 1.6.2.1 | SALIDA PARA TV CABLE | 20d | 2022-05-02 | 2022-05-22 | 280SS | 130d |  | día 1036 | día 1056 | 9540 |
| 286 | 1.6.2.2 | SALIDA PARA RED DATA | 20d | 2022-05-02 | 2022-05-22 | 280SS | 130d |  | día 1036 | día 1056 | 9540 |
| 287 | 1.6.2.3 | SALIDA PARA VIDEO | 20d | 2022-05-02 | 2022-05-22 | 280SS | 130d |  | día 1036 | día 1056 | 9540 |
| 288 | 1.6.2.4 | SALIDA PARA TIMBRE | 20d | 2022-05-02 | 2022-05-22 | 280SS | 130d |  | día 1036 | día 1056 | 9540 |
| 289 | 1.6.2.5 | SALIDA PARA CAMPANILLA TIMBRE | 20d | 2022-05-02 | 2022-05-22 | 280SS | 130d |  | día 1036 | día 1056 | 9540 |
| 290 | 1.6.2.6 | SALIDA PARA DETECTOR DE ALARMA CONTRA INCENDIO (NO INCLUYE CABLEADO NI EQUIPO) | 20d | 2022-05-02 | 2022-05-22 | 280SS | 130d |  | día 1036 | día 1056 | 9540 |
| 291 | 1.6.2.7 | SALIDA PARA PULSADOR Y CAMPANILLA DE ALARMA CONTRA INCENDIO | 20d | 2022-05-02 | 2022-05-22 | 280SS | 130d |  | día 1036 | día 1056 | 9540 |
| 292 | 1.6.2.8 | SALIDA PARA CENTRAL DE ALARMA CONTRA INCENDIO (NO INCLUYE CABLEADO NI EQUIPO) | 20d | 2022-05-02 | 2022-05-22 | 280SS | 130d |  | día 1036 | día 1056 | 9540 |
| 293 | 1.6.2.9 | SALIDA PARA PARLANTE | 20d | 2022-05-02 | 2022-05-22 | 280SS | 130d |  | día 1036 | día 1056 | 9540 |
| 294 | 1.6.2.10 | SALIDA PARA MICROFONO | 20d | 2022-05-02 | 2022-05-22 | 280SS | 130d | 0d | día 1036 | día 1056 | 9540 |

| ID | WBS | Task | Duration | Start | Finish | Predecessors | Total slack | Free slack | Comienzo de Tarea | Fin de Tarea | Días Calendarios |
| --- | --- | --- | --- | --- | --- | --- | --- | --- | --- | --- | --- |
| 295 | 1.6.3 | **CONDUCTOR Y ACCESORIOS** | 20d | 2022-05-02 | 2022-05-22 |  | 130d |  |  |  |  |
| 296 | 1.6.3.1 | ALIMENTADOR NH -80 PVC-SAP Ø20mm | 20d | 2022-05-02 | 2022-05-22 | 294SS | 130d |  | día 1036 | día 1056 | 9540 |
| 297 | 1.6.3.2 | ALIMENTADOR CABLE N2XOH 2-1X16mm2 + 1X10mm2, D=50mm | 20d | 2022-05-02 | 2022-05-22 | 294SS | 130d |  | día 1036 | día 1056 | 9540 |
| 298 | 1.6.3.3 | ALIMENTADOR CABLE N2XOH 2-1X 6mm2 + 1X6mm2, D=25mm | 20d | 2022-05-02 | 2022-05-22 | 294SS | 130d |  | día 1036 | día 1056 | 9540 |
| 299 | 1.6.3.4 | ALIMENTADOR CABLE N2XOH 2-1X 16mm2 + 1X10(N) +1X10 (T) mm2 | 20d | 2022-05-02 | 2022-05-22 | 294SS | 130d |  | día 1036 | día 1056 | 9540 |
| 300 | 1.6.4 | **EQUIPOS DE CLIMATIZACION** | 7d | 2022-05-02 | 2022-05-09 |  | 143d |  |  |  |  |
| 301 | 1.6.4.1 | VENTILADOR DE TECHO 150w | 7d | 2022-05-02 | 2022-05-09 | 294SS | 143d |  | día 1036 | día 1043 | 3300 |
| 302 | 1.6.5 | **FLETE TERRESTRE** | 20d | 2022-05-26 | 2022-06-15 |  | 106d |  |  |  |  |
| 303 | 1.6.5.1 | FLETE TERRESTRE- CEREZAL. | 20d | 2022-05-26 | 2022-06-15 | 187SS | 106d |  | día 1060 | día 1080 | 9540 |
| 304 | 1.7 | **CERCO PERIMETRICO** | 64d | 2022-05-02 | 2022-07-05 |  | 86d |  |  |  |  |
| 305 | 1.7.1 | **OBRAS PRELIMINARES** | 7d | 2022-05-02 | 2022-05-09 |  | 86d |  |  |  |  |
| 306 | 1.7.1.1 | TRAZO Y REPLANTEO DURANTE EL PROCESO | 7d | 2022-05-02 | 2022-05-09 |  | 86d | 0d | día 1036 | día 1043 | 3300 |
| 307 | 1.7.1.2 | LIMPIEZA PERMANENTE Y FINAL DE LA OBRA | 3d | 2022-05-02 | 2022-05-05 | 306SS | 86d | 0d | día 1036 | día 1039 | 1380 |
| 308 | 1.7.2 | **ESTRUCTURAS** | 34d | 2022-05-02 | 2022-06-05 |  | 86d |  |  |  |  |
| 309 | 1.7.2.1 | **MOVIMIENTO DE TIERRAS** | 21d | 2022-05-02 | 2022-05-23 |  | 86d |  |  |  |  |
| 310 | 1.7.2.1.1 | **CORTES Y EXCAVACION** | 20d | 2022-05-02 | 2022-05-22 |  | 86d |  |  |  |  |
| 311 | 1.7.2.1.1.1 | EXCAV. ZANJAS PARA CIMIENTO Y ZAPATAS | 10d | 2022-05-12 | 2022-05-22 | 313 | 86d | 0d | día 1046 | día 1056 | 4740 |
| 312 | 1.7.2.1.1.2 | EXCAVACIÓN MANUAL CIMIENTO CORRIDO | 10d | 2022-05-12 | 2022-05-22 | 311SS | 86d | 0d | día 1046 | día 1056 | 4740 |
| 313 | 1.7.2.1.1.3 | EXCAVACION DE MATERIAL CONTAMINADO H=0.10 | 10d | 2022-05-02 | 2022-05-12 | 307SS | 86d | 0d | día 1036 | día 1046 | 4740 |
| 314 | 1.7.2.1.2 | **RELLENOS** | 21d | 2022-05-02 | 2022-05-23 |  | 98d |  |  |  |  |
| 315 | 1.7.2.1.2.1 | RELLENO COMPACTADO C/EQUIPO MAT/PROPIO | 8d | 2022-05-15 | 2022-05-23 | 317SS+1d | 86d | 0d | día 1049 | día 1057 | 3780 |
| 316 | 1.7.2.1.2.2 | RELLENO COMPACTADO C/EQUIPO MAT/PRESTAMO AFIRMADO | 5d | 2022-05-02 | 2022-05-07 |  | 145d |  | día 1036 | día 1041 | 2340 |
| 317 | 1.7.2.1.2.3 | NIVELACIÓN DE TERRENO Y COMPACTACION | 8d | 2022-05-14 | 2022-05-22 | 312SS+2d | 86d | 0d | día 1048 | día 1056 | 3780 |
| 318 | 1.7.2.1.3 | **ACARREO Y ELIMINACION DE MATERIAL** | 14d | 2022-05-02 | 2022-05-16 |  | 136d |  |  |  |  |
| 319 | 1.7.2.1.3.1 | ACARREO INTERNO, MATERIAL PROCEDENTE DE EXCAVACIONES | 10d | 2022-05-02 | 2022-05-12 |  | 140d |  | día 1036 | día 1046 | 4740 |
| 320 | 1.7.2.1.3.2 | ELIMINACION DE MATERIAL EXCEDENTE CON EQUIPO | 3d | 2022-05-13 | 2022-05-16 | 312SS+1d | 136d |  | día 1047 | día 1050 | 1380 |

| ID | WBS | Task | Duration | Start | Finish | Predecessors | Total slack | Free slack | Comienzo de Tarea | Fin de Tarea | Días Calendarios |
| --- | --- | --- | --- | --- | --- | --- | --- | --- | --- | --- | --- |
| 321 | 1.7.2.2 | **OBRAS DE CONCRETO SIMPLE** | 8d | 2022-05-16 | 2022-05-24 |  | 86d |  |  |  |  |
| 322 | 1.7.2.2.1 | **SOLADO** | 8d | 2022-05-16 | 2022-05-24 |  | 128d |  |  |  |  |
| 323 | 1.7.2.2.1.1 | SOLADO PARA ZAPATAS e=4", 1:12 CEM/HORM | 8d | 2022-05-16 | 2022-05-24 | 315SS+1d | 128d |  | día 1050 | día 1058 | 3780 |
| 324 | 1.7.2.2.2 | **CIMIENTOS** | 8d | 2022-05-16 | 2022-05-24 |  | 86d |  |  |  |  |
| 325 | 1.7.2.2.2.1 | CIMIENTO CORRIDO 1:10 + 30 % P.G. f'c >=100Kg/cm2 | 8d | 2022-05-16 | 2022-05-24 | 315SS+1d | 86d | 0d | día 1050 | día 1058 | 3780 |
| 326 | 1.7.2.3 | **OBRAS DE CONCRETO ARMADO** | 24d | 2022-05-12 | 2022-06-05 |  | 92d |  |  |  |  |
| 327 | 1.7.2.3.1 | **SOBRECIMIENTOS REFORZADOS** | 9d | 2022-05-18 | 2022-05-27 |  | 86d |  |  |  |  |
| 328 | 1.7.2.3.1.1 | SOBRECIMIENTO- CONCRETO f'c=175 kg/cm2 | 8d | 2022-05-19 | 2022-05-27 | 329SS+1d | 86d | 0d | día 1053 | día 1061 | 3780 |
| 329 | 1.7.2.3.1.2 | SOBRECIMIENTO-ENCOFRADO Y DESENCOFRADO | 8d | 2022-05-18 | 2022-05-26 | 325SS+2d | 86d | 0d | día 1052 | día 1060 | 3780 |
| 330 | 1.7.2.3.1.3 | ACERO DE REFUERZO F'y=4200 kg/cm2 | 8d | 2022-05-18 | 2022-05-26 | 329SS | 126d |  | día 1052 | día 1060 | 3780 |
| 331 | 1.7.2.3.2 | **ZAPATAS** | 16d | 2022-05-12 | 2022-05-28 |  | 116d |  |  |  |  |
| 332 | 1.7.2.3.2.1 | ZAPATAS, CONCRETO f'c=210 kg/cm² | 15d | 2022-05-13 | 2022-05-28 | 333SS+1d | 116d | 0d | día 1047 | día 1062 | 7140 |
| 333 | 1.7.2.3.2.2 | ZAPATAS, ACERO Fy=4200 kg/cm² | 15d | 2022-05-12 | 2022-05-27 | 311SS | 116d | 0d | día 1046 | día 1061 | 7140 |
| 334 | 1.7.2.3.3 | **COLUMNAS** | 21d | 2022-05-14 | 2022-06-04 |  | 116d |  |  |  |  |
| 335 | 1.7.2.3.3.1 | COLUMNAS, CONCRETO f'c=210 kg/cm² | 20d | 2022-05-15 | 2022-06-04 | 336SS+1d | 117d |  | día 1049 | día 1069 | 9540 |
| 336 | 1.7.2.3.3.2 | COLUMNAS, ENCOFRADO Y DESENCOFRADO | 20d | 2022-05-14 | 2022-06-03 | 332SS+1d | 116d | 0d | día 1048 | día 1068 | 9540 |
| 337 | 1.7.2.3.3.3 | COLUMNAS, ACERO Fy=4200 kg/cm² | 20d | 2022-05-14 | 2022-06-03 | 332SS+1d | 118d |  | día 1048 | día 1068 | 9540 |
| 338 | 1.7.2.3.4 | **VIGAS** | 15d | 2022-05-21 | 2022-06-05 |  | 116d |  |  |  |  |
| 339 | 1.7.2.3.4.1 | VIGAS, CONCRETO f'c=210 kg/cm² | 15d | 2022-05-21 | 2022-06-05 | 336SS+7d | 116d |  | día 1055 | día 1070 | 7140 |
| 340 | 1.7.2.3.4.2 | VIGAS, ENCOFRADO Y DESENCOFRADO | 15d | 2022-05-21 | 2022-06-05 | 336SS+7d | 116d |  | día 1055 | día 1070 | 7140 |
| 341 | 1.7.2.3.4.3 | VIGAS, ACERO Fy=4200 kg/cm² | 15d | 2022-05-21 | 2022-06-05 | 336SS+7d | 116d |  | día 1055 | día 1070 | 7140 |
| 342 | 1.7.3 | **ARQUITECTURA** | 40d | 2022-05-26 | 2022-07-05 |  | 86d |  |  |  |  |
| 343 | 1.7.3.1 | **MUROS Y TABIQUES DE ALBAÑILERIA** | 30d | 2022-05-26 | 2022-06-25 |  | 86d |  |  |  |  |
| 344 | 1.7.3.1.1 | MURO DE LADRILLO KK TIPO IV SOGA M:1:1:4 E=1.5 cm | 30d | 2022-05-26 | 2022-06-25 | 328SS+7d | 86d | 0d | día 1060 | día 1090 | 14340 |
| 345 | 1.7.3.1.2 | ALAMBRE # 8 REFUERZO HORIZONTAL EN MUROS | 30d | 2022-05-26 | 2022-06-25 | 328SS+7d | 96d |  | día 1060 | día 1090 | 14340 |

| ID | WBS | Task | Duration | Start | Finish | Predecessors | Total slack | Free slack | Comienzo de Tarea | Fin de Tarea | Días Calendarios |
| --- | --- | --- | --- | --- | --- | --- | --- | --- | --- | --- | --- |
| 346 | 1.7.3.2 | **REVOQUES Y REVESTIMIENTOS** | 26d | 2022-05-29 | 2022-06-24 |  | 90d |  |  |  |  |
| 347 | 1.7.3.2.1 | TARRAJEO DE COLUMNAS | 21d | 2022-05-29 | 2022-06-19 | 344SS+3d | 90d | 0d | día 1063 | día 1084 | 10020 |
| 348 | 1.7.3.2.2 | TARRAJEO DE VIGAS | 25d | 2022-05-30 | 2022-06-24 | 347SS+1d | 97d |  | día 1064 | día 1089 | 11940 |
| 349 | 1.7.3.3 | **CONTRAZOCALOS** | 16d | 2022-05-29 | 2022-06-14 |  | 107d |  |  |  |  |
| 350 | 1.7.3.3.1 | CONTRAZOCALO CEMENTO SIN COLOREAR H = 30 cm | 16d | 2022-05-29 | 2022-06-14 | 347SS | 107d |  | día 1063 | día 1079 | 7620 |
| 351 | 1.7.3.4 | **PINTURA** | 16d | 2022-06-19 | 2022-07-05 |  | 86d |  |  |  |  |
| 352 | 1.7.3.4.1 | PINTURA LATEX 2 MANOS EN MUROS Y COLUMNA -CERCO PERIMETRICO | 10d | 2022-06-25 | 2022-07-05 | 344 | 86d |  | día 1090 | día 1100 | 4740 |
| 353 | 1.7.3.4.2 | PINTURA EN VIGAS Y COLUMNAS | 12d | 2022-06-19 | 2022-07-01 | 347 | 90d |  | día 1084 | día 1096 | 5700 |
| 354 | 1.7.4 | **FLETE TERRESTRE ESTUCTURAS** | 30d | 2022-05-09 | 2022-06-08 |  | 113d |  |  |  |  |
| 355 | 1.7.4.1 | FLETE - TERRESTRE. | 30d | 2022-05-09 | 2022-06-08 | 306 | 113d |  | día 1043 | día 1073 | 14340 |
| 356 | 1.8 | **TECHO PARABOLICO** | 104d | 2022-05-02 | 2022-08-14 |  | 46d |  |  |  |  |
| 357 | 1.8.1 | **TRABAJOS PRELIMINARES** | 6d | 2022-05-02 | 2022-05-08 |  | 46d |  |  |  |  |
| 358 | 1.8.1.1 | NIVELACION, TRAZO Y REPLANTEO PRELIMINAR | 6d | 2022-05-02 | 2022-05-08 |  | 46d | 0d | día 1036 | día 1042 | 2820 |
| 359 | 1.8.1.2 | LIMPIEZA PERMANENTE Y FINAL DE LA OBRA | 3d | 2022-05-02 | 2022-05-05 | 358SS | 147d |  | día 1036 | día 1039 | 1380 |
| 360 | 1.8.2 | **ESTRUCTURAS** | 104d | 2022-05-02 | 2022-08-14 |  | 46d |  | día 0 | día 1 | 420 |
| 361 | 1.8.2.1 | **MOVIMIENTO DE TIERRAS** | 104d | 2022-05-02 | 2022-08-14 |  | 46d |  |  |  |  |
| 362 | 1.8.2.1.1 | EXCAVACION DE ZANJAS | 6d | 2022-05-02 | 2022-05-08 | 358SS | 46d | 0d | día 1036 | día 1042 | 2820 |
| 363 | 1.8.2.1.2 | NIVELACION Y COMPACTACION EN FONDO DE ZANJAS | 4d | 2022-05-03 | 2022-05-07 | 362SS+1d | 144d | 0d | día 1037 | día 1041 | 1860 |
| 364 | 1.8.2.1.3 | RELLENO CON MATERIAL -HORMIGON | 2d | 2022-05-03 | 2022-05-05 | 363SS | 147d | 0d | día 1037 | día 1039 | 900 |
| 365 | 1.8.2.1.4 | RELLENO Y COMPACTACION CON MATERIAL PROPIO ALR.DE COLUMNA DE C° | 2d | 2022-05-03 | 2022-05-05 | 364SS | 147d |  | día 1037 | día 1039 | 900 |
| 366 | 1.8.2.1.5 | BASE DE AFIRMADO PARA LOSA DE CONCRETO e=0.10 m | 1d | 2022-05-07 | 2022-05-08 | 363 | 144d |  | día 1041 | día 1042 | 420 |
| 367 | 1.8.2.1.6 | ACARREO INTERNO, MAT. PROCEDENTE DE EXCAVACIONES | 2d | 2022-05-02 | 2022-05-04 | 362SS | 148d | 0d | día 1036 | día 1038 | 900 |
| 368 | 1.8.2.1.7 | ELIMINACIÓN DE MATERIAL EXCEDENTE DP= 5km | 1d | 2022-05-02 | 2022-05-03 | 367SS | 149d |  | día 1036 | día 1037 | 420 |
| 369 | 1.8.2.1.8 | **OBRAS DE CONCRETO SIMPLE** | 24d | 2022-05-02 | 2022-05-26 |  | 47d |  |  |  |  |
| 370 | 1.8.2.1.8.1 | CONCRETO SOLADO MEZCLA 1:10 CEMENTO - HORMIGON E=0.10M | 2d | 2022-05-03 | 2022-05-05 | 362SS+1d | 147d |  | día 1037 | día 1039 | 900 |

| ID | WBS | Task | Duration | Start | Finish | Predecessors | Total slack | Free slack | Comienzo de Tarea | Fin de Tarea | Días Calendarios |
| --- | --- | --- | --- | --- | --- | --- | --- | --- | --- | --- | --- |
| 371 | 1.8.2.1.8.2 | **OBRAS DE CONCRETO ARMADO** | 24d | 2022-05-02 | 2022-05-26 |  | 47d |  |  |  |  |
| 372 | 1.8.2.1.8.2.1 | **ZAPATAS** | 12d | 2022-05-03 | 2022-05-15 |  | 46d |  |  |  |  |
| 373 | 1.8.2.1.8.2.1.1 | ZAPATAS, CONCRETO f'c=210 kg/cm² | 6d | 2022-05-09 | 2022-05-15 | 374 | 46d | 0d | día 1043 | día 1049 | 2820 |
| 374 | 1.8.2.1.8.2.1.2 | ZAPATAS, ACERO Fy=4200 kg/cm² | 6d | 2022-05-03 | 2022-05-09 | 362SS+1d | 46d | 0d | día 1037 | día 1043 | 2820 |
| 375 | 1.8.2.1.8.2.2 | **VIGAS DE CIMENTACION** | 8d | 2022-05-02 | 2022-05-10 |  | 142d |  |  |  |  |
| 376 | 1.8.2.1.8.2.2.1 | VIGAS DE CIMENTACION, CONCRETO f'c=210 kg/cm² | 7d | 2022-05-03 | 2022-05-10 | 377SS+1d | 142d |  | día 1037 | día 1044 | 3300 |
| 377 | 1.8.2.1.8.2.2.2 | ENCOFRADO Y DESENCOFRADO PARA VIGAS DE CIMENTACION | 7d | 2022-05-02 | 2022-05-09 | 362SS | 142d | 0d | día 1036 | día 1043 | 3300 |
| 378 | 1.8.2.1.8.2.2.3 | VIGAS DE CIMENTACION, ACERO Fy=4,200 kg/cm² | 7d | 2022-05-02 | 2022-05-09 | 377SS | 143d |  | día 1036 | día 1043 | 3300 |
| 379 | 1.8.2.1.8.2.3 | **COLUMNAS** | 17d | 2022-05-09 | 2022-05-26 |  | 46d |  |  |  |  |
| 380 | 1.8.2.1.8.2.3.1 | COLUMNAS, CONCRETO f'c=210 kg/cm² | 11d | 2022-05-11 | 2022-05-22 | 382SS+2d | 46d | 0d | día 1045 | día 1056 | 5220 |
| 381 | 1.8.2.1.8.2.3.2 | COLUMNAS, ENCOFRADO Y DESENCOFRADO | 10d | 2022-05-10 | 2022-05-20 | 373SS+1d | 132d |  | día 1044 | día 1054 | 4740 |
| 382 | 1.8.2.1.8.2.3.3 | COLUMNAS, ACERO Fy=4200 kg/cm² | 10d | 2022-05-09 | 2022-05-19 | 373SS | 46d | 0d | día 1043 | día 1053 | 4740 |
| 383 | 1.8.2.1.8.2.3.4 | SUMINISTRO Y COLOCACION DE PERNOS DE ACLANJE | 10d | 2022-05-16 | 2022-05-26 | 380SS+5d | 46d | 0d | día 1050 | día 1060 | 4740 |
| 384 | 1.8.2.1.9 | **ESTRUCTURAS METALICAS** | 30d | 2022-06-15 | 2022-07-15 |  | 46d |  |  |  |  |
| 385 | 1.8.2.1.9.1 | COLUMNA METALICA DE 12'' X 10.31mm | 30d | 2022-06-15 | 2022-07-15 | 383FS+20d | 76d |  | día 1080 | día 1110 | 14340 |
| 386 | 1.8.2.1.9.2 | VIGA DE PLANCHA METALICA DE 8''X12''X 3 1/16'' | 30d | 2022-06-15 | 2022-07-15 | 383FS+20d | 76d |  | día 1080 | día 1110 | 14340 |
| 387 | 1.8.2.1.9.3 | TIJERAL METALICO EN ARCO(SEGUN PLANO) | 30d | 2022-06-15 | 2022-07-15 | 383FS+20d | 76d |  | día 1080 | día 1110 | 14340 |
| 388 | 1.8.2.1.9.4 | VIGUETA METALICA 4"X2"X 1/8" | 30d | 2022-06-15 | 2022-07-15 | 383FS+20d | 76d |  | día 1080 | día 1110 | 14340 |
| 389 | 1.8.2.1.9.5 | APOYO METALICO FIJO Y/0 MOVIL | 30d | 2022-06-15 | 2022-07-15 | 383FS+20d | 76d |  | día 1080 | día 1110 | 14340 |
| 390 | 1.8.2.1.9.6 | TEMPLADOR CABLE TIPO BOA 5/8'' | 30d | 2022-06-15 | 2022-07-15 | 383FS+20d | 76d |  | día 1080 | día 1110 | 14340 |
| 391 | 1.8.2.1.9.7 | COBERTURA CURVA METALICA ALUZINC E=0.40mm | 30d | 2022-06-15 | 2022-07-15 | 383FS+20d | 76d |  | día 1080 | día 1110 | 14340 |
| 392 | 1.8.2.1.9.8 | CANALETA DE FIERRO GALVANIZADO EN TECHO | 30d | 2022-06-15 | 2022-07-15 | 383FS+20d | 46d | 0d | día 1080 | día 1110 | 14340 |
| 393 | 1.8.2.1.10 | **FLETE TERRESTRE ESTUCTURAS** | 30d | 2022-05-16 | 2022-06-15 |  | 106d |  |  |  |  |
| 394 | 1.8.2.1.10.1 | FLETE - TERRESTRE. | 30d | 2022-05-16 | 2022-06-15 | 383SS | 106d |  | día 1050 | día 1080 | 14340 |

| ID | WBS | Task | Duration | Start | Finish | Predecessors | Total slack | Comienzo de Tarea | Fin de Tarea | Días Calendarios |
| --- | --- | --- | --- | --- | --- | --- | --- | --- | --- | --- |
| 395 | 1.8.2.1.11 | **MOBILIARIO** | 15d | 2022-07-30 | 2022-08-14 |  | 46d | día 0 | día 1 | 420 |
| 396 | 1.8.2.1.11.1 | MOBILIARIO Y EQUIPAMIENTO DE AULAS | 15d | 2022-07-30 | 2022-08-14 | 392FS+15d | 46d | día 1125 | día 1140 | 7140 |
| 397 | 1.8.2.1.11.2 | MOBILIARIO Y EQUIPAMIENTO EN MODULO (AULAS+BIBLIOTECA+ALMACEN) | 15d | 2022-07-30 | 2022-08-14 | 392FS+15d | 46d | día 1125 | día 1140 | 7140 |
| 398 | 1.8.2.1.11.3 | MOBILIARIO Y EQUIPAMIENTO EN MODULO ADMINISTRATIVO | 15d | 2022-07-30 | 2022-08-14 | 392FS+15d | 46d | día 1125 | día 1140 | 7140 |
| 399 | 1.8.2.1.11.4 | MOBILIARIO Y EQUIPAMIENTO EN MODULO SUM | 15d | 2022-07-30 | 2022-08-14 | 392FS+15d | 46d | día 1125 | día 1140 | 7140 |
| 400 | 1.8.2.1.11.5 | MOBILIARIO Y EQUIPAMIENTO EN MODULO COCINA + DEPOSITO | 15d | 2022-07-30 | 2022-08-14 | 392FS+15d | 46d | día 1125 | día 1140 | 7140 |
